# WBS - GED

Schedule from MS Project, 2014-01-06 to 2014-12-30, costs in R$.

## Calendars

- Padrão: Mon-Fri 09:00-12:00, 13:00-18:00; Sat-Sun off.

## Resources

| Resource | Group | Rate |
| --- | --- | --- |
| Gerente do Projeto | PROJ | 28.9 |
| Diretor Administrativo | ADM | 38 |
| Diretor Executivo | ADM | 35 |
| Analista de Projetos 1 | PROJ | 15 |
| Diretor de TI | TI | 41 |
| Analista de TI 1 | TI | 25 |
| Analista de TI 2 | TI | 25 |
| Diretor de Engenharia | ADM | 34.5 |
| Comprador 1 | SUP | 9.88 |
| Comprador 2 | SUP | 9.88 |
| RH | RH | 13.75 |

## Schedule

| ID | WBS | Task | Type | Duration | Start | Finish | Predecessors | Total slack | Free slack | Resources | Work | Cost |
| --- | --- | --- | --- | --- | --- | --- | --- | --- | --- | --- | --- | --- |
| 1 | 1 | **GED - Gerenciamento Eletrônico de Documentos** |  | 256.88d? | 2014-01-06 | 2014-12-30 |  | 0d |  |  | 9757h | 287,294.34 |
| 2 | 1.1 | **Gerenciamento do Projeto** |  | 256.88d? | 2014-01-06 | 2014-12-30 |  | 0d |  |  | 7069h | 205,031.7 |
| 3 | 1.1.1 | **Planejamento do Projeto** |  | 113d | 2014-01-06 | 2014-06-11 |  | 1.54d | 0d |  | 904h | 26,863.2 |
| 4 | 1.1.1.1 | **Declaração de Escopo** |  | 33d | 2014-01-06 | 2014-02-19 |  | 1.54d | 0d |  | 264h | 7,629.6 |
| 5 | 1.1.1.1.1 | Inicio | milestone | 0d | 2014-01-06 | 2014-01-06 |  | 1.54d | 0d |  |  |  |
| 6 | 1.1.1.1.2 | Coletar Requisitos |  | 10d | 2014-01-06 | 2014-01-17 | 5 | 1.54d | 0d | Gerente do Projeto | 80h | 2,312 |
| 7 | 1.1.1.1.3 | Redigir Draft de Escopo #1 |  | 5d | 2014-01-20 | 2014-01-24 | 6 | 1.54d | 0d | Gerente do Projeto | 40h | 1,156 |
| 8 | 1.1.1.1.4 | Alinhar/Refinar Escopo com o Cliente |  | 10d | 2014-01-27 | 2014-02-07 | 7 | 1.54d | 0d | Gerente do Projeto | 80h | 2,312 |
| 9 | 1.1.1.1.5 | Refinar Escopo |  | 3d | 2014-02-10 | 2014-02-12 | 8 | 1.54d | 0d | Gerente do Projeto | 24h | 693.6 |
| 10 | 1.1.1.1.6 | Aprovar Escopo |  | 5d | 2014-02-13 | 2014-02-19 | 9 | 1.54d |  | Gerente do Projeto | 40h | 1,156 |
| 11 | 1.1.1.2 | **EAP / Dicionário da EAP** |  | 20d | 2014-02-20 | 2014-03-19 | 4 | 1.54d | 0d |  | 160h | 4,624 |
| 12 | 1.1.1.2.1 | Detalhar Escopo |  | 5d | 2014-02-20 | 2014-02-26 |  | 1.54d | 0d | Gerente do Projeto | 40h | 1,156 |
| 13 | 1.1.1.2.2 | Alinhar Definições do Dicionário com o Cliente |  | 15d | 2014-02-27 | 2014-03-19 | 12 | 1.54d |  | Gerente do Projeto | 120h | 3,468 |
| 14 | 1.1.1.3 | **Análise de Viabilidade** |  | 18d | 2014-03-20 | 2014-04-14 | 11 | 1.54d | 0d |  | 144h | 5,035.2 |
| 15 | 1.1.1.3.1 | Estimar Custo do Gerenciamento Não-eletrônico de Documentos |  | 5d | 2014-03-20 | 2014-03-26 |  | 1.54d | 0d | Diretor Administrativo | 40h | 1,520 |
| 16 | 1.1.1.3.2 | Estimar Economia de Recursos |  | 3d | 2014-03-27 | 2014-03-31 | 15 | 1.54d | 0d | Gerente do Projeto | 24h | 693.6 |
| 17 | 1.1.1.3.3 | Estimar Custo do Projeto |  | 3d | 2014-04-01 | 2014-04-03 | 16 | 1.54d | 0d | Gerente do Projeto | 24h | 693.6 |
| 18 | 1.1.1.3.4 | Documentar Análise |  | 2d | 2014-04-04 | 2014-04-07 | 17 | 1.54d | 0d | Diretor Administrativo | 16h | 608 |
| 19 | 1.1.1.3.5 | Aprovar Análise de Viabilidade |  | 5d | 2014-04-08 | 2014-04-14 | 18 | 1.54d |  | Diretor Administrativo | 40h | 1,520 |
| 20 | 1.1.1.4 | **Planejamento de Tempo do Projeto** |  | 17d | 2014-04-15 | 2014-05-07 | 14 | 1.54d | 0d |  | 136h | 4,174.4 |
| 21 | 1.1.1.4.1 | Definir Lista de Atividades |  | 3d | 2014-04-15 | 2014-04-17 |  | 1.54d | 0d | Gerente do Projeto | 24h | 693.6 |
| 22 | 1.1.1.4.2 | Montar Diagrama de Rede |  | 1d | 2014-04-18 | 2014-04-18 | 21 | 1.54d | 0d | Gerente do Projeto | 8h | 231.2 |
| 23 | 1.1.1.4.3 | Listar Recursos Disponíveis |  | 3d | 2014-04-21 | 2014-04-23 | 22 | 1.54d | 0d | Gerente do Projeto | 24h | 693.6 |
| 24 | 1.1.1.4.4 | Estimar Duração das Atividades e do Projeto |  | 5d | 2014-04-24 | 2014-04-30 | 23 | 1.54d | 0d | Gerente do Projeto | 40h | 1,156 |
| 25 | 1.1.1.4.5 | Aprovar Cronograma |  | 5d | 2014-05-01 | 2014-05-07 | 24 | 1.54d |  | Diretor Executivo | 40h | 1,400 |

| ID | WBS | Task | Duration | Start | Finish | Predecessors | Total slack | Free slack | Constraint | Resources | Work | Cost |
| --- | --- | --- | --- | --- | --- | --- | --- | --- | --- | --- | --- | --- |
| 26 | 1.1.1.5 | **Planejamento de Custos do Projeto** | 15d | 2014-05-08 | 2014-05-28 | 20 | 1.54d | 0d |  |  | 120h | 4,200 |
| 27 | 1.1.1.5.1 | Realizar Análise Make or Buy | 3d | 2014-05-08 | 2014-05-12 |  | 1.54d | 0d |  | Diretor Executivo | 24h | 840 |
| 28 | 1.1.1.5.2 | Solicitar Orçamentos | 3d | 2014-05-13 | 2014-05-15 | 27 | 1.54d | 0d |  | Diretor Executivo | 24h | 840 |
| 29 | 1.1.1.5.3 | Analisar Custos por Atividade Make | 2d | 2014-05-16 | 2014-05-19 | 28 | 1.54d | 0d |  | Diretor Executivo | 16h | 560 |
| 30 | 1.1.1.5.4 | Analisar Fluxo de Caixa do Projeto | 2d | 2014-05-20 | 2014-05-21 | 29 | 1.54d | 0d |  | Diretor Executivo | 16h | 560 |
| 31 | 1.1.1.5.5 | Aprovar Custos | 5d | 2014-05-22 | 2014-05-28 | 30 | 1.54d |  |  | Diretor Executivo | 40h | 1,400 |
| 32 | 1.1.1.6 | **Planejamento de Qualidade do Projeto** | 10d | 2014-05-29 | 2014-06-11 | 26 | 1.54d |  |  |  | 80h | 1,200 |
| 33 | 1.1.1.6.1 | Definir Parâmetros de Qualidade | 5d | 2014-05-29 | 2014-06-04 |  | 1.54d | 0d |  | Analista de Projetos 1 | 40h | 600 |
| 34 | 1.1.1.6.2 | Definir Pontos de Controle | 3d | 2014-06-05 | 2014-06-09 | 33 | 1.54d | 0d |  | Analista de Projetos 1 | 24h | 360 |
| 35 | 1.1.1.6.3 | Definir Sistema de Controle de Mudanças | 2d | 2014-06-10 | 2014-06-11 | 34 | 1.54d |  |  | Analista de Projetos 1 | 16h | 240 |
| 36 | 1.1.2 | **Monitoramento e Controle do Projeto** | 256.88d? | 2014-01-06 | 2014-12-30 |  | 0d |  |  |  | 6165h | 178,168.5 |
| 37 | 1.1.2.1 | Controlar Tempo | 256.88d? | 2014-01-06 | 2014-12-30 |  | 0d |  | finish no earlier than 2014-12-30 | Gerente do Projeto | 2055h | 59,389.5 |
| 38 | 1.1.2.2 | Controlar Custos | 256.88d? | 2014-01-06 | 2014-12-30 |  | 0d |  | finish no earlier than 2014-12-30 | Gerente do Projeto | 2055h | 59,389.5 |
| 39 | 1.1.2.3 | Controlar Qualidade | 256.88d? | 2014-01-06 | 2014-12-30 |  | 0d |  | finish no earlier than 2014-12-30 | Gerente do Projeto | 2055h | 59,389.5 |
| 40 | 1.2 | **Tipologia de Documentos** | 39d | 2014-06-12 | 2014-08-05 | 3 | 1.54d | 0d |  |  | 312h | 7,800 |
| 41 | 1.2.1 | **Análise de Documentos em Arquivo Corrente** | 13d | 2014-06-12 | 2014-06-30 |  | 1.54d | 0d |  |  | 104h | 2,600 |
| 42 | 1.2.1.1 | Tipificar Documentos em Arquivo Corrente | 3d | 2014-06-12 | 2014-06-16 |  | 1.54d | 0d |  | Analista de TI 1 | 24h | 600 |
| 43 | 1.2.1.2 | Definir Tabela de Temporalidade do Arquivo Corrente | 3d | 2014-06-17 | 2014-06-19 | 42 | 1.54d | 0d |  | Analista de TI 1 | 24h | 600 |
| 44 | 1.2.1.3 | Quantificar Documentos em Arquivo Corrente | 2d | 2014-06-20 | 2014-06-23 | 43 | 1.54d | 0d |  | Analista de TI 1 | 16h | 400 |
| 45 | 1.2.1.4 | Padronizar Métodos de Arquivamento | 5d | 2014-06-24 | 2014-06-30 | 44 | 1.54d |  |  | Analista de TI 1 | 40h | 1,000 |
| 46 | 1.2.2 | **Análise de Documentos em Arquivo Intermediário** | 13d | 2014-07-01 | 2014-07-17 | 41 | 1.54d | 0d |  |  | 104h | 2,600 |
| 47 | 1.2.2.1 | Tipificar Documentos em Arquivo Intermediário | 3d | 2014-07-01 | 2014-07-03 |  | 1.54d | 0d |  | Analista de TI 1 | 24h | 600 |
| 48 | 1.2.2.2 | Definir Tabela de Temporalidade do Arquivo Intermediário | 3d | 2014-07-04 | 2014-07-08 | 47 | 1.54d | 0d |  | Analista de TI 1 | 24h | 600 |
| 49 | 1.2.2.3 | Quantificar Documentos em Arquivo Intermediário | 2d | 2014-07-09 | 2014-07-10 | 48 | 1.54d | 0d |  | Analista de TI 1 | 16h | 400 |
| 50 | 1.2.2.4 | Padronizar Métodos de Arquivamento | 5d | 2014-07-11 | 2014-07-17 | 49 | 1.54d |  |  | Analista de TI 1 | 40h | 1,000 |

| ID | WBS | Task | Duration | Start | Finish | Predecessors | Total slack | Free slack | Resources | Work | Cost |
| --- | --- | --- | --- | --- | --- | --- | --- | --- | --- | --- | --- |
| 51 | 1.2.3 | **Análise de Documentos em Arquivo Permanente** | 13d | 2014-07-18 | 2014-08-05 | 46 | 1.54d |  |  | 104h | 2,600 |
| 52 | 1.2.3.1 | Tipificar Documentos em Arquivo Permanente | 3d | 2014-07-18 | 2014-07-22 |  | 1.54d | 0d | Analista de TI 2 | 24h | 600 |
| 53 | 1.2.3.2 | Definir Tabela de Temporalidade do Arquivo Permanente | 3d | 2014-07-23 | 2014-07-25 | 52 | 1.54d | 0d | Analista de TI 2 | 24h | 600 |
| 54 | 1.2.3.3 | Quantificar Documentos em Arquivo Permanente | 2d | 2014-07-28 | 2014-07-29 | 53 | 1.54d | 0d | Analista de TI 2 | 16h | 400 |
| 55 | 1.2.3.4 | Padronizar Métodos de Arquivamento | 5d | 2014-07-30 | 2014-08-05 | 54 | 1.54d |  | Analista de TI 2 | 40h | 1,000 |
| 56 | 1.3 | **Definição de Processos** | 37d | 2014-08-06 | 2014-09-25 | 40 | 1.54d | 0d |  | 552h | 17,624 |
| 57 | 1.3.1 | **Definição de Entrada de Dados** | 8d | 2014-08-06 | 2014-08-15 |  | 1.54d | 0d |  | 128h | 3,200 |
| 58 | 1.3.1.1 | Analisar Diferentes Entradas de Dados | 3d | 2014-08-06 | 2014-08-08 |  | 1.54d | 0d | Analista de TI 1; Analista de TI 2 | 48h | 1,200 |
| 59 | 1.3.1.2 | Definir Processos de Entrada | 5d | 2014-08-11 | 2014-08-15 | 58 | 1.54d |  | Analista de TI 1; Analista de TI 2 | 80h | 2,000 |
| 60 | 1.3.2 | **Definição de Perfis de Acesso** | 5d | 2014-08-18 | 2014-08-22 | 57 | 1.54d | 0d |  | 40h | 1,640 |
| 61 | 1.3.2.1 | Identificar Funcionários Autorizados | 3d | 2014-08-18 | 2014-08-20 |  | 1.54d | 0d | Diretor de TI | 24h | 984 |
| 62 | 1.3.2.2 | Definir Grupos e Permissões de Acesso | 2d | 2014-08-21 | 2014-08-22 | 61 | 1.54d |  | Diretor de TI | 16h | 656 |
| 63 | 1.3.3 | **Definição de Descarte e Permanência de Documentos Impressos e Digitais** | 8d | 2014-08-25 | 2014-09-03 | 60 | 1.54d | 0d |  | 104h | 4,072 |
| 64 | 1.3.3.1 | Definir Procedimentos para Descarte de Documentos Impressos | 3d | 2014-08-25 | 2014-08-27 |  | 1.54d | 0d | Diretor Administrativo | 24h | 912 |
| 65 | 1.3.3.2 | Definir Procedimentos para Descarte de Documentos Digitais | 2d | 2014-08-28 | 2014-08-29 | 64 | 1.54d | 0d | Diretor Administrativo; Diretor de TI | 32h | 1,264 |
| 66 | 1.3.3.3 | Definir Procedimentos para Arquivo Permanente | 3d | 2014-09-01 | 2014-09-03 | 65 | 1.54d |  | Diretor Administrativo; Diretor de TI | 48h | 1,896 |
| 67 | 1.3.4 | **Manual de Procedimentos** | 16d | 2014-09-04 | 2014-09-25 | 63 | 1.54d |  |  | 280h | 8,712 |
| 68 | 1.3.4.1 | Reunir Padronizações de Arquivos Corrente, Intermediário e Permanente | 2d | 2014-09-04 | 2014-09-05 |  | 1.54d | 0d | Analista de TI 1; Analista de TI 2 | 32h | 800 |
| 69 | 1.3.4.2 | Consolidar Procedimentos de Descarte e Permanência | 2d | 2014-09-08 | 2014-09-09 | 68 | 1.54d | 0d | Analista de TI 1; Analista de TI 2 | 32h | 800 |
| 70 | 1.3.4.3 | Redigir Manual de Procedimentos para Organização de Arquivos | 5d | 2014-09-10 | 2014-09-16 | 69 | 1.54d | 0d | Analista de TI 1; Analista de TI 2 | 80h | 2,000 |
| 71 | 1.3.4.4 | Aprovar Manual de Procedimentos | 5d | 2014-09-17 | 2014-09-23 | 70 | 1.54d | 0d | Diretor Administrativo; Diretor de TI; Diretor Executivo | 120h | 4,560 |
| 72 | 1.3.4.5 | Distribuir Manual de Procedimentos | 2d | 2014-09-24 | 2014-09-25 | 71 | 1.54d |  | Diretor de Engenharia | 16h | 552 |
| 73 | 1.4 | **Aquisições e Contratações** | 22.33d | 2014-09-26 | 2014-10-28 | 56 | 1.54d | 0d |  | 896h | 28,854.24 |
| 74 | 1.4.1 | **Aquisição de Hardware** | 17d | 2014-09-26 | 2014-10-20 |  | 6.88d |  |  | 304h | 9,722.08 |
| 75 | 1.4.1.1 | Analisar Necessidades de Impressoras | 2d | 2014-09-26 | 2014-09-29 |  | 6.88d | 0d | Diretor Administrativo; Diretor Executivo; Analista de TI 1 | 48h | 1,568 |
| 76 | 1.4.1.2 | Analisar Necessidades de Scanners | 2d | 2014-09-30 | 2014-10-01 | 75 | 6.88d | 0d | Diretor Administrativo; Diretor Executivo; Analista de TI 1 | 48h | 1,568 |
| 77 | 1.4.1.3 | Analisar Demais Necessidades | 3d | 2014-10-02 | 2014-10-06 | 76 | 6.88d | 0d | Diretor Administrativo; Diretor Executivo | 48h | 1,752 |
| 78 | 1.4.1.4 | Solicitar Orçamentos | 3d | 2014-10-07 | 2014-10-09 | 77 | 6.88d | 0d | Analista de TI 1 | 24h | 600 |
| 79 | 1.4.1.5 | Aprovar Custos | 5d | 2014-10-10 | 2014-10-16 | 78 | 6.88d | 0d | Diretor Administrativo; Diretor Executivo; Gerente do Projeto | 120h | 4,076 |
| 80 | 1.4.1.6 | Realizar Compras | 2d | 2014-10-17 | 2014-10-20 | 79 | 6.88d |  | Comprador 1 | 16h | 158.08 |

| ID | WBS | Task | Duration | Start | Finish | Predecessors | Total slack | Free slack | Resources | Work | Cost |
| --- | --- | --- | --- | --- | --- | --- | --- | --- | --- | --- | --- |
| 81 | 1.4.2 | **Aquisição de Softwares** | 22.33d | 2014-09-26 | 2014-10-28 |  | 1.54d |  |  | 232h | 6,342.08 |
| 82 | 1.4.2.1 | Analisar Necessidades de Software OCR | 3d | 2014-09-26 | 2014-09-30 |  | 1.54d | 0d | Analista de TI 2 | 24h | 600 |
| 83 | 1.4.2.2 | Analisar Necessidades de Assinatura Digital e Criptografia | 3d | 2014-10-01 | 2014-10-03 | 82 | 1.54d | 0d | Analista de TI 2 | 24h | 600 |
| 84 | 1.4.2.3 | Analisar Necessidades de Integração com ERP | 3d | 2014-10-06 | 2014-10-08 | 83 | 1.54d | 0d | Analista de TI 2 | 24h | 600 |
| 85 | 1.4.2.4 | Analisar Demais Necessidades | 5d | 2014-10-09 | 2014-10-15 | 84 | 1.54d | 0d | Analista de TI 2 | 40h | 1,000 |
| 86 | 1.4.2.5 | Solicitar Orçamentos | 3d | 2014-10-16 | 2014-10-20 | 85 | 1.54d | 0d | Analista de TI 2 | 24h | 600 |
| 87 | 1.4.2.6 | Aprovar Custos | 3.33d | 2014-10-21 | 2014-10-24 | 86 | 1.54d | 0d | Diretor de Engenharia; Diretor de TI; Gerente do Projeto | 80h | 2,784 |
| 88 | 1.4.2.7 | Realizar Compras | 2d | 2014-10-24 | 2014-10-28 | 87 | 1.54d |  | Comprador 2 | 16h | 158.08 |
| 89 | 1.4.3 | **Contratação de Serviço de Hospedagem de Dados** | 21d | 2014-09-26 | 2014-10-24 |  | 2.88d |  |  | 360h | 12,790.08 |
| 90 | 1.4.3.1 | Analisar Requisitos de Rede para Cloud Service | 3d | 2014-09-26 | 2014-09-30 |  | 2.88d | 0d | Diretor de Engenharia; Diretor de TI | 48h | 1,812 |
| 91 | 1.4.3.2 | Analisar Necessidades de Segurança de Documentos | 3d | 2014-10-01 | 2014-10-03 | 90 | 2.88d | 0d | Diretor de Engenharia; Diretor de TI | 48h | 1,812 |
| 92 | 1.4.3.3 | Analisar Serviços Disponíveis | 5d | 2014-10-06 | 2014-10-10 | 91 | 2.88d | 0d | Diretor de Engenharia; Diretor de TI | 80h | 3,020 |
| 93 | 1.4.3.4 | Solicitar Orçamentos | 3d | 2014-10-13 | 2014-10-15 | 92 | 2.88d | 0d | Diretor de Engenharia; Diretor de TI | 48h | 1,812 |
| 94 | 1.4.3.5 | Aprovar Custos | 5d | 2014-10-16 | 2014-10-22 | 93 | 2.88d | 0d | Diretor de Engenharia; Diretor de TI; Gerente do Projeto | 120h | 4,176 |
| 95 | 1.4.3.6 | Realizar Contratação | 2d | 2014-10-23 | 2014-10-24 | 94 | 2.88d |  | Comprador 1 | 16h | 158.08 |
| 96 | 1.5 | **Implementação do Sistema** | 30d | 2014-10-28 | 2014-12-09 | 73 | 1.54d | 0d |  | 640h | 19,174 |
| 97 | 1.5.1 | **Instalação de Hardware** | 4d | 2014-10-28 | 2014-11-03 |  | 1.54d | 0d |  | 64h | 1,600 |
| 98 | 1.5.1.1 | Instalar Hardware de Entrada de Dados | 2d | 2014-10-28 | 2014-10-30 |  | 1.54d | 0d | Analista de TI 1; Analista de TI 2 | 32h | 800 |
| 99 | 1.5.1.2 | Instalar Hardware de Saída de Dados | 2d | 2014-10-30 | 2014-11-03 | 98 | 1.54d |  | Analista de TI 1; Analista de TI 2 | 32h | 800 |
| 100 | 1.5.2 | **Instalação e Configuração no Servidor** | 6d | 2014-11-03 | 2014-11-11 | 97 | 1.54d | 0d |  | 120h | 3,696 |
| 101 | 1.5.2.1 | Instalar Sistema Central de GED | 3d | 2014-11-03 | 2014-11-06 |  | 1.54d | 0d | Analista de TI 2 | 24h | 600 |
| 102 | 1.5.2.2 | Configurar Perfis de Acesso e Permissões de Leitura | 3d | 2014-11-06 | 2014-11-11 | 101 | 1.54d |  | Analista de TI 1; Analista de TI 2; Diretor Administrativo; Diretor de TI | 96h | 3,096 |
| 103 | 1.5.3 | **Instalação e Configuração nas Estações de Trabalho** | 15d | 2014-11-11 | 2014-12-02 | 100 | 1.54d | 0d |  | 320h | 9,090 |
| 104 | 1.5.3.1 | Instalar Sistema Cliente de GED | 5d | 2014-11-11 | 2014-11-18 |  | 1.54d | 0d | Analista de TI 1; Analista de TI 2 | 80h | 2,000 |
| 105 | 1.5.3.2 | Configurar Acesso Pessoal | 5d | 2014-11-18 | 2014-11-25 | 104 | 1.54d | 0d | Analista de TI 1; Analista de TI 2; Diretor Administrativo; Diretor de Engenharia; Diretor de TI | 200h | 6,540 |
| 106 | 1.5.3.3 | Treinar Funcionário para Acesso | 5d | 2014-11-25 | 2014-12-02 | 105 | 1.54d |  | RH | 40h | 550 |

| ID | WBS | Task | Type | Duration | Start | Finish | Predecessors | Total slack | Free slack | Resources | Work | Cost |
| --- | --- | --- | --- | --- | --- | --- | --- | --- | --- | --- | --- | --- |
| 107 | 1.5.4 | **Testes e Homologação da Solução** |  | 5d | 2014-12-02 | 2014-12-09 | 103 | 1.54d |  |  | 136h | 4,788 |
| 108 | 1.5.4.1 | Testar Acessos Cliente-Servidor |  | 2d | 2014-12-02 | 2014-12-04 |  | 1.54d | 0d | Analista de TI 1; Analista de TI 2; Diretor Administrativo; Diretor de TI | 64h | 2,064 |
| 109 | 1.5.4.2 | Homologar Solução de GED |  | 3d | 2014-12-04 | 2014-12-09 | 108 | 1.54d |  | Diretor Administrativo; Diretor de Engenharia; Diretor de TI | 72h | 2,724 |
| 110 | 1.6 | **Encerramento do Projeto** |  | 14d | 2014-12-09 | 2014-12-29 | 96 | 1.54d |  |  | 288h | 8,810.4 |
| 111 | 1.6.1 | **Encerramento dos Contratos** |  | 2d | 2014-12-09 | 2014-12-11 |  | 1.54d | 0d |  | 16h | 559.2 |
| 112 | 1.6.1.1 | Encerrar Contratos de TI |  | 1d | 2014-12-09 | 2014-12-10 |  | 1.54d | 0d | Diretor de TI; Gerente do Projeto | 16h | 559.2 |
| 113 | 1.6.1.2 | Encerrar Outros Contratos |  | 1d | 2014-12-10 | 2014-12-11 | 112 | 1.54d |  |  |  |  |
| 114 | 1.6.2 | **Relatório de Lições Aprendidas** |  | 6d | 2014-12-11 | 2014-12-19 | 111 | 1.54d | 0d |  | 216h | 6,744 |
| 115 | 1.6.2.1 | Solicitar feedback das áreas envolvidas |  | 1d | 2014-12-11 | 2014-12-12 |  | 1.54d | 0d | Diretor Administrativo; Diretor Executivo | 16h | 584 |
| 116 | 1.6.2.2 | Reunir soluções a problemas encontrados |  | 3d | 2014-12-12 | 2014-12-17 | 115 | 1.54d | 0d | Analista de TI 1; Analista de TI 2; Diretor Administrativo; Diretor de Engenharia; Diretor de TI; Diretor Executivo; Gerente do Projeto | 168h | 5,457.6 |
| 117 | 1.6.2.3 | Redigir Relatório de Lições Aprendidas |  | 2d | 2014-12-17 | 2014-12-19 | 116 | 1.54d |  | Gerente do Projeto; Analista de Projetos 1 | 32h | 702.4 |
| 118 | 1.6.3 | **Relatório do Projeto** |  | 6d | 2014-12-19 | 2014-12-29 | 114 | 1.54d |  |  | 56h | 1,507.2 |
| 119 | 1.6.3.1 | Reunir Documentação do Projeto |  | 1d | 2014-12-19 | 2014-12-22 |  | 1.54d | 0d | Analista de Projetos 1; Gerente do Projeto | 16h | 351.2 |
| 120 | 1.6.3.2 | Redigir Relatório de Desempenho do Projeto |  | 5d | 2014-12-22 | 2014-12-29 | 119 | 1.54d | 0d | Gerente do Projeto | 40h | 1,156 |
| 121 | 1.6.3.3 | Término | milestone | 0d | 2014-12-29 | 2014-12-29 | 120 | 1.54d |  |  |  |  |
