# ImplantacaoSGQ

Schedule from MS Project, 2017-01-03 to 2018-01-09, status date 2017-01-26, costs in R$, A marks actual dates.

## Calendars

- Padrão: Mon-Fri 09:00-12:00, 13:00-18:00; Sat-Sun off.

## Resources

| Resource | Rate | Cost per use |
| --- | --- | --- |
| Consultor | 35 |  |
| Representante da direção | 25 |  |
| Engenheiro | 35 |  |
| Mestre de obras | 20 |  |
| Diretor | 50 |  |
| Gerente de RH | 25 |  |
| Gerente de Compras | 25 |  |
| Gerente Almoxarifado | 25 |  |
| Gerente Financeiro | 25 |  |
| Gerente Comercial | 25 |  |
| Técnico de Segurança | 12.5 |  |
| Técnico em Edificações | 12.5 |  |
| Datashow | 2 |  |
| Computador | 5 |  |
| Impressora | 3 |  |
| Papel A4 |  | 7 |
| Empresa Consultoria Externa |  |  |
| Orgão Certificador |  |  |
| Gerente de Obras | 25 |  |
| Gerente de Aquisições | 25 |  |
| Gerente Administrativo | 25 |  |
| Auditor | 30 |  |
| Aluguel de carro |  | 500 |

## Schedule

| ID | WBS | Task | Type | Duration | Start | Finish | Predecessors | Complete | Remaining | Baseline start | Baseline finish | Baseline duration | Total slack | Free slack | Constraint | Resources | Work | Actual work | Cost | Baseline cost | Actual cost |
| --- | --- | --- | --- | --- | --- | --- | --- | --- | --- | --- | --- | --- | --- | --- | --- | --- | --- | --- | --- | --- | --- |
| 1 | 1 | **Implantação do SGQ** |  | 266d | 2017-01-03 A | 2018-01-09 |  | 1% | 262.38d | 2017-01-02 | 2018-01-05 | 265d | 0d |  |  |  | 2127.75h | 132.75h | 55,464.75 | 54,164 | 2,589.75 |
| 2 | 1.1 | **TAREFAS PRELIMINARES** |  | 9.88d | 2017-01-03 A | 2017-01-16 |  | 54% | 4.51d | 2017-01-02 | 2017-01-09 | 6d | 256.12d |  |  |  | 204.75h | 132.75h | 4,128.75 | 2,828 | 2,589.75 |
| 3 | 1.1.1 | **DIAGNÓSTICO** |  | 3.88d | 2017-01-03 A | 2017-01-06 |  | 74% | 1d | 2017-01-02 | 2017-01-05 | 4d | 261.12d |  |  |  | 85h | 69h | 1,316 | 1,359 | 996 |
| 4 | 1.1.1.1 | Coletar dados |  | 1d | 2017-01-03 A | 2017-01-03 A |  | 100% |  | 2017-01-02 | 2017-01-02 | 1d |  |  |  | Computador; Consultor; Impressora; Papel A4 | 24h | 24h | 351 | 351 | 351 |
| 5 | 1.1.1.2 | Transformar dados em informação |  | 1.88d | 2017-01-04 A | 2017-01-05 A |  | 100% |  | 2017-01-03 | 2017-01-04 | 2d |  |  | start no earlier than 2017-01-04 | Computador; Consultor; Impressora | 45h | 45h | 645 | 688 | 645 |
| 6 | 1.1.1.3 | Criar apresentação |  | 1d | 2017-01-05 | 2017-01-06 | 5 |  |  | 2017-01-05 | 2017-01-05 | 1d | 261.12d | 1d |  | Computador; Consultor | 16h |  | 320 | 320 |  |
| 7 | 1.1.2 | **REUNIÃO COM A DIRETORIA** |  | 1d | 2017-01-09 | 2017-01-10 |  |  |  | 2017-01-06 | 2017-01-06 | 1d | 260.12d |  |  |  | 51h |  | 1,094 | 1,094 |  |
| 8 | 1.1.2.1 | Apresentar informações coletadas |  | 1d | 2017-01-09 | 2017-01-10 | 6 |  |  | 2017-01-06 | 2017-01-06 | 1d | 260.12d | 0d | finish no earlier than 2017-01-10 | Computador; Datashow; Gerente Almoxarifado; Gerente Comercial; Gerente de Compras; Gerente de RH; Gerente Financeiro | 50h |  | 1,044 | 1,044 |  |
| 9 | 1.1.2.2 | Obter o aval da empresa |  | 1d | 2017-01-09 | 2017-01-10 | 8FF |  |  | 2017-01-06 | 2017-01-06 | 1d | 260.12d |  |  | Diretor [12.5%] | 1h |  | 50 | 50 |  |
| 10 | 1.1.3 | **APRESENTAÇÃO DO SGQ PARA EQUIPE** |  | 1.88d | 2017-01-13 A | 2017-01-16 |  | 65% | 0.65d | 2017-01-09 | 2017-01-09 | 1d | 254.12d |  |  |  | 68.75h | 63.75h | 1,718.75 | 375 | 1,593.75 |
| 11 | 1.1.3.1 | Apresentar o esboço do plano de ação |  | 1.88d | 2017-01-13 A | 2017-01-16 A | 9 | 100% |  | 2017-01-09 | 2017-01-09 | 1d |  |  |  | Gerente Almoxarifado; Gerente Comercial [25%]; Gerente de Compras; Gerente de RH; Gerente Financeiro | 63.75h | 63.75h | 1,593.75 | 250 | 1,593.75 |
| 12 | 1.1.3.2 | Combinar visita aos setores |  | 1d | 2017-01-13 | 2017-01-16 | 11FF |  |  | 2017-01-09 | 2017-01-09 | 1d | 254.12d | 0d |  | Gerente Almoxarifado; Gerente Comercial [12.5%]; Gerente de Compras; Gerente de RH; Gerente Financeiro | 5h |  | 125 | 125 |  |
| 13 | 1.2 | **PLANEJAMENTO** |  | 47.12d | 2017-01-12 | 2017-03-20 |  |  |  | 2017-01-10 | 2017-03-16 | 47.12d | 0d |  |  |  | 1122h |  | 30,022 | 30,022 |  |
| 14 | 1.2.1 | **Administração** |  | 12d | 2017-01-12 | 2017-01-27 |  |  |  | 2017-01-10 | 2017-01-25 | 12d | 0d |  |  |  | 171h |  | 4,277 | 4,277 |  |
| 15 | 1.2.1.1 | Entrevistar responsável |  | 1d | 2017-01-12 | 2017-01-12 |  |  |  | 2017-01-10 | 2017-01-10 | 1d | 0d |  | start no earlier than 2017-01-12 | Consultor; Gerente Administrativo | 16h |  | 480 | 480 |  |
| 16 | 1.2.1.2 | Mapear processo |  | 1d | 2017-01-13 | 2017-01-13 | 15 |  |  | 2017-01-11 | 2017-01-11 | 1d | 0d |  |  | Consultor; Computador | 16h |  | 320 | 320 |  |
| 17 | 1.2.1.3 | Reunião com equipe |  | 1d | 2017-01-16 | 2017-01-16 | 16 |  |  | 2017-01-12 | 2017-01-12 | 1d | 0d |  |  | Consultor | 8h |  | 280 | 280 |  |
| 18 | 1.2.1.4 | Redesenhar processo |  | 1d | 2017-01-17 | 2017-01-17 | 17 |  |  | 2017-01-13 | 2017-01-13 | 1d | 0d |  |  | Consultor | 8h |  | 280 | 280 |  |
| 19 | 1.2.1.5 | Aprovar processo |  | 1d | 2017-01-18 | 2017-01-18 | 18 |  |  | 2017-01-16 | 2017-01-16 | 1d | 0d |  |  | Gerente Administrativo; Representante da direção | 9h |  | 225 | 225 |  |
| 20 | 1.2.1.6 | Criar documentação |  | 2d | 2017-01-19 | 2017-01-20 | 19 |  |  | 2017-01-17 | 2017-01-18 | 2d | 0d |  |  | Computador; Consultor; Impressora | 48h |  | 688 | 688 |  |
| 21 | 1.2.1.7 | Treinar gestor |  | 3d | 2017-01-23 | 2017-01-25 | 20 |  |  | 2017-01-19 | 2017-01-23 | 3d | 0d |  |  | Consultor; Gerente Comercial | 48h |  | 1,440 | 1,440 |  |
| 22 | 1.2.1.8 | Treinar equipe |  | 2d | 2017-01-26 | 2017-01-27 | 21 |  |  | 2017-01-24 | 2017-01-25 | 2d | 0d |  |  | Consultor; Datashow | 18h |  | 564 | 564 |  |
| 23 | 1.2.1.9 | Término do treinamento | milestone | 0d | 2017-01-27 | 2017-01-27 | 22, 21 |  |  | 2017-01-25 | 2017-01-25 | 0d | 247d |  |  |  |  |  |  |  |  |
| 24 | 1.2.2 | **Aquisição** |  | 10d | 2017-01-16 | 2017-01-27 |  |  |  | 2017-01-10 | 2017-01-25 | 12d | 211.88d |  |  |  | 147h |  | 4,029 | 4,029 |  |
| 25 | 1.2.2.1 | Entrevistar responsável |  | 1d | 2017-01-16 | 2017-01-17 | 12 |  |  | 2017-01-10 | 2017-01-10 | 1d | 254.12d | 0d |  | Consultor; Gerente de Aquisições | 16h |  | 480 | 480 |  |
| 26 | 1.2.2.2 | Mapear processo |  | 1d | 2017-01-17 | 2017-01-18 | 25 |  |  | 2017-01-11 | 2017-01-11 | 1d | 254.12d |  |  | Consultor; Computador | 16h |  | 320 | 320 |  |
| 27 | 1.2.2.3 | Reunião com equipe |  | 1d | 2017-01-16 | 2017-01-16 |  |  |  | 2017-01-12 | 2017-01-12 | 1d | 211.88d | 0d | start no earlier than 2017-01-16 | Consultor | 8h |  | 280 | 280 |  |
| 28 | 1.2.2.4 | Redesenhar processo |  | 1d | 2017-01-17 | 2017-01-17 | 27 |  |  | 2017-01-13 | 2017-01-13 | 1d | 211.88d | 0d |  | Consultor | 8h |  | 280 | 280 |  |
| 29 | 1.2.2.5 | Aprovar processo |  | 1d | 2017-01-18 | 2017-01-18 | 28 |  |  | 2017-01-16 | 2017-01-16 | 1d | 211.88d | 0d |  | Gerente de Aquisições; Representante da direção [12.5%] | 9h |  | 225 | 225 |  |
| 30 | 1.2.2.6 | Criar documentação |  | 2d | 2017-01-19 | 2017-01-20 | 29 |  |  | 2017-01-17 | 2017-01-18 | 2d | 211.88d | 0d |  | Computador; Consultor | 32h |  | 640 | 640 |  |
| 31 | 1.2.2.7 | Treinar gestor |  | 2d | 2017-01-23 | 2017-01-24 | 30 |  |  | 2017-01-19 | 2017-01-20 | 2d | 211.88d | 0d | start no earlier than 2017-01-23 | Consultor; Gerente de Aquisições | 32h |  | 960 | 960 |  |
| 32 | 1.2.2.8 | Treinar equipe |  | 3d | 2017-01-25 | 2017-01-27 | 31 |  |  | 2017-01-23 | 2017-01-25 | 3d | 211.88d | 0d | start no earlier than 2017-01-25 | Consultor; Datashow | 26h |  | 844 | 844 |  |
| 33 | 1.2.2.9 | Término do treinamento | milestone | 0d | 2017-01-27 | 2017-01-27 | 32, 31 |  |  | 2017-01-25 | 2017-01-25 | 0d | 211.88d | 0d |  |  |  |  |  |  |  |

| ID | WBS | Task | Type | Duration | Start | Finish | Predecessors | Baseline start | Baseline finish | Baseline duration | Total slack | Free slack | Constraint | Resources | Work | Cost | Baseline cost |
| --- | --- | --- | --- | --- | --- | --- | --- | --- | --- | --- | --- | --- | --- | --- | --- | --- | --- |
| 34 | 1.2.3 | **Almoxarifado** |  | 12d | 2017-01-30 | 2017-02-14 |  | 2017-01-26 | 2017-02-10 | 12d | 235d |  |  |  | 171h | 4,849 | 4,849 |
| 35 | 1.2.3.1 | Entrevistar responsável |  | 1d | 2017-01-30 | 2017-01-30 | 33 | 2017-01-26 | 2017-01-26 | 1d | 235d | 0d | finish no earlier than 2017-01-25 | Consultor; Gerente Almoxarifado | 16h | 480 | 480 |
| 36 | 1.2.3.2 | Mapear processo |  | 1d | 2017-01-31 | 2017-01-31 | 35 | 2017-01-27 | 2017-01-27 | 1d | 235d | 0d |  | Consultor; Computador; Aluguel de carro | 24h | 820 | 820 |
| 37 | 1.2.3.3 | Reunião com equipe |  | 1d | 2017-02-01 | 2017-02-01 | 36 | 2017-01-30 | 2017-01-30 | 1d | 235d | 0d |  | Consultor | 8h | 280 | 280 |
| 38 | 1.2.3.4 | Redesenhar processo |  | 1d | 2017-02-02 | 2017-02-02 | 37 | 2017-01-31 | 2017-01-31 | 1d | 235d | 0d |  | Consultor | 8h | 280 | 280 |
| 39 | 1.2.3.5 | Aprovar processo |  | 1d | 2017-02-03 | 2017-02-03 | 38 | 2017-02-01 | 2017-02-01 | 1d | 235d | 0d |  | Gerente Almoxarifado; Representante da direção | 9h | 225 | 225 |
| 40 | 1.2.3.6 | Criar documentação |  | 2d | 2017-02-06 | 2017-02-07 | 39 | 2017-02-02 | 2017-02-03 | 2d | 235d | 0d |  | Computador; Consultor | 48h | 960 | 960 |
| 41 | 1.2.3.7 | Treinar gestor |  | 2d | 2017-02-08 | 2017-02-09 | 40 | 2017-02-06 | 2017-02-07 | 2d | 235d | 0d |  | Consultor; Gerente Almoxarifado | 32h | 960 | 960 |
| 42 | 1.2.3.8 | Treinar equipe |  | 3d | 2017-02-10 | 2017-02-14 | 41 | 2017-02-08 | 2017-02-10 | 3d | 235d | 0d |  | Consultor; Datashow | 26h | 844 | 844 |
| 43 | 1.2.3.9 | Término do treinamento | milestone | 0d | 2017-02-14 | 2017-02-14 | 42, 41 | 2017-02-10 | 2017-02-10 | 0d | 235d |  |  |  |  |  |  |
| 44 | 1.2.4 | **RH** |  | 11.12d | 2017-01-30 | 2017-02-14 |  | 2017-01-26 | 2017-02-10 | 11.12d | 211.88d |  |  |  | 138h | 3,724 | 3,724 |
| 45 | 1.2.4.1 | Entrevistar responsável |  | 1d | 2017-01-30 | 2017-01-30 | 33 | 2017-01-26 | 2017-01-26 | 1d | 211.88d | 0d |  | Consultor; Gerente de RH | 10h | 330 | 330 |
| 46 | 1.2.4.2 | Mapear processo |  | 1d | 2017-01-31 | 2017-01-31 | 45 | 2017-01-27 | 2017-01-27 | 1d | 211.88d | 0d |  | Consultor; Computador | 16h | 320 | 320 |
| 47 | 1.2.4.3 | Reunião com equipe |  | 1d | 2017-02-01 | 2017-02-01 | 46 | 2017-01-30 | 2017-01-30 | 1d | 211.88d | 0d |  | Consultor | 8h | 280 | 280 |
| 48 | 1.2.4.4 | Redesenhar processo |  | 1d | 2017-02-02 | 2017-02-02 | 47 | 2017-01-31 | 2017-01-31 | 1d | 211.88d | 0d |  | Consultor | 8h | 280 | 280 |
| 49 | 1.2.4.5 | Aprovar processo |  | 0.12d | 2017-02-03 | 2017-02-03 | 48 | 2017-02-01 | 2017-02-01 | 0.12d | 211.88d | 0d |  | Gerente de RH; Representante da direção | 2h | 50 | 50 |
| 50 | 1.2.4.6 | Criar documentação |  | 2d | 2017-02-03 | 2017-02-07 | 49 | 2017-02-01 | 2017-02-03 | 2d | 211.88d | 0d |  | Computador; Consultor | 48h | 960 | 960 |
| 51 | 1.2.4.7 | Treinar gestor |  | 2d | 2017-02-07 | 2017-02-09 | 50 | 2017-02-03 | 2017-02-07 | 2d | 211.88d | 0d |  | Consultor; Gerente de RH | 20h | 660 | 660 |
| 52 | 1.2.4.8 | Treinar equipe |  | 3d | 2017-02-09 | 2017-02-14 | 51 | 2017-02-07 | 2017-02-10 | 3d | 211.88d | 0d |  | Consultor; Datashow | 26h | 844 | 844 |
| 53 | 1.2.4.9 | Término do treinamento | milestone | 0d | 2017-02-14 | 2017-02-14 | 51, 52 | 2017-02-10 | 2017-02-10 | 0d | 211.88d | 0d |  |  |  |  |  |
| 54 | 1.2.5 | **FINANCEIRO** |  | 12d | 2017-02-14 | 2017-03-02 |  | 2017-02-10 | 2017-02-28 | 12d | 223.88d |  |  |  | 163h | 4,349 | 4,349 |
| 55 | 1.2.5.1 | Entrevistar responsável |  | 1d | 2017-02-14 | 2017-02-15 | 53 | 2017-02-10 | 2017-02-13 | 1d | 223.88d | 0d |  | Consultor; Gerente Financeiro | 16h | 480 | 480 |
| 56 | 1.2.5.2 | Mapear processo |  | 1d | 2017-02-15 | 2017-02-16 | 55 | 2017-02-13 | 2017-02-14 | 1d | 223.88d | 0d |  | Consultor; Computador | 16h | 320 | 320 |
| 57 | 1.2.5.3 | Reunião com equipe |  | 1d | 2017-02-16 | 2017-02-17 | 56 | 2017-02-14 | 2017-02-15 | 1d | 223.88d | 0d |  | Consultor | 8h | 280 | 280 |
| 58 | 1.2.5.4 | Redesenhar processo |  | 1d | 2017-02-17 | 2017-02-20 | 57 | 2017-02-15 | 2017-02-16 | 1d | 223.88d | 0d |  | Consultor | 8h | 280 | 280 |
| 59 | 1.2.5.5 | Aprovar processo |  | 1d | 2017-02-20 | 2017-02-21 | 58 | 2017-02-16 | 2017-02-17 | 1d | 223.88d | 0d |  | Gerente Financeiro; Representante da direção | 9h | 225 | 225 |
| 60 | 1.2.5.6 | Criar documentação |  | 2d | 2017-02-21 | 2017-02-23 | 59 | 2017-02-17 | 2017-02-21 | 2d | 223.88d | 0d |  | Computador; Consultor | 48h | 960 | 960 |
| 61 | 1.2.5.7 | Treinar gestor |  | 2d | 2017-02-23 | 2017-02-27 | 60 | 2017-02-21 | 2017-02-23 | 2d | 223.88d | 0d |  | Consultor; Gerente Financeiro | 32h | 960 | 960 |
| 62 | 1.2.5.8 | Treinar equipe |  | 3d | 2017-02-27 | 2017-03-02 | 61 | 2017-02-23 | 2017-02-28 | 3d | 223.88d | 0d |  | Consultor; Datashow | 26h | 844 | 844 |
| 63 | 1.2.5.9 | Término do treinamento | milestone | 0d | 2017-03-02 | 2017-03-02 | 61, 62 | 2017-02-28 | 2017-02-28 | 0d | 223.88d |  |  |  |  |  |  |

| ID | WBS | Task | Type | Duration | Start | Finish | Predecessors | Baseline start | Baseline finish | Baseline duration | Total slack | Free slack | Resources | Work | Cost | Baseline cost |
| --- | --- | --- | --- | --- | --- | --- | --- | --- | --- | --- | --- | --- | --- | --- | --- | --- |
| 64 | 1.2.6 | **COMERCIAL** |  | 12d | 2017-02-14 | 2017-03-02 |  | 2017-02-10 | 2017-02-28 | 12d | 211.88d |  |  | 161h | 4,345 | 4,345 |
| 65 | 1.2.6.1 | Entrevistar responsável |  | 1d | 2017-02-14 | 2017-02-15 | 53 | 2017-02-10 | 2017-02-13 | 1d | 211.88d | 0d | Gerente Comercial; Consultor | 16h | 480 | 480 |
| 66 | 1.2.6.2 | Mapear processo |  | 1d | 2017-02-15 | 2017-02-16 | 65 | 2017-02-13 | 2017-02-14 | 1d | 211.88d | 0d | Consultor; Computador | 16h | 320 | 320 |
| 67 | 1.2.6.3 | Reunião com equipe |  | 1d | 2017-02-16 | 2017-02-17 | 66 | 2017-02-14 | 2017-02-15 | 1d | 211.88d | 0d | Consultor | 8h | 280 | 280 |
| 68 | 1.2.6.4 | Redesenhar processo |  | 1d | 2017-02-17 | 2017-02-20 | 67 | 2017-02-15 | 2017-02-16 | 1d | 211.88d | 0d | Consultor | 8h | 280 | 280 |
| 69 | 1.2.6.5 | Aprovar processo |  | 1d | 2017-02-20 | 2017-02-21 | 68 | 2017-02-16 | 2017-02-17 | 1d | 211.88d | 0d | Gerente Comercial; Representante da direção | 9h | 225 | 225 |
| 70 | 1.2.6.6 | Criar documentação |  | 2d | 2017-02-21 | 2017-02-23 | 69 | 2017-02-17 | 2017-02-21 | 2d | 211.88d | 0d | Computador; Consultor | 48h | 960 | 960 |
| 71 | 1.2.6.7 | Treinar gestor |  | 2d | 2017-02-23 | 2017-02-27 | 70 | 2017-02-21 | 2017-02-23 | 2d | 211.88d | 0d | Consultor; Gerente Comercial | 32h | 960 | 960 |
| 72 | 1.2.6.8 | Treinar equipe |  | 3d | 2017-02-27 | 2017-03-02 | 71 | 2017-02-23 | 2017-02-28 | 3d | 211.88d | 0d | Consultor | 24h | 840 | 840 |
| 73 | 1.2.6.9 | Término do treinamento | milestone | 0d | 2017-03-02 | 2017-03-02 | 71, 72 | 2017-02-28 | 2017-02-28 | 0d | 211.88d | 0d |  |  |  |  |
| 74 | 1.2.7 | **OBRA** |  | 12d | 2017-03-02 | 2017-03-20 |  | 2017-02-28 | 2017-03-16 | 12d | 211.88d |  |  | 171h | 4,449 | 4,449 |
| 75 | 1.2.7.1 | Entrevistar responsável |  | 1d | 2017-03-02 | 2017-03-03 | 73 | 2017-02-28 | 2017-03-01 | 1d | 211.88d | 0d | Consultor; Gerente de Obras | 16h | 480 | 480 |
| 76 | 1.2.7.2 | Mapear processo |  | 1d | 2017-03-03 | 2017-03-06 | 75 | 2017-03-01 | 2017-03-02 | 1d | 211.88d | 0d | Consultor; Computador; Técnico de Segurança | 24h | 420 | 420 |
| 77 | 1.2.7.3 | Reunião com equipe |  | 1d | 2017-03-06 | 2017-03-07 | 76 | 2017-03-02 | 2017-03-03 | 1d | 211.88d | 0d | Consultor | 8h | 280 | 280 |
| 78 | 1.2.7.4 | Redesenhar processo |  | 1d | 2017-03-07 | 2017-03-08 | 77 | 2017-03-03 | 2017-03-06 | 1d | 211.88d | 0d | Consultor | 8h | 280 | 280 |
| 79 | 1.2.7.5 | Aprovar processo |  | 1d | 2017-03-08 | 2017-03-09 | 78 | 2017-03-06 | 2017-03-07 | 1d | 211.88d | 0d | Gerente de Obras; Representante da direção [12.5%] | 9h | 225 | 225 |
| 80 | 1.2.7.6 | Criar documentação |  | 2d | 2017-03-09 | 2017-03-13 | 79 | 2017-03-07 | 2017-03-09 | 2d | 211.88d | 0d | Computador; Consultor | 48h | 960 | 960 |
| 81 | 1.2.7.7 | Treinar gestor |  | 2d | 2017-03-13 | 2017-03-15 | 80 | 2017-03-09 | 2017-03-13 | 2d | 211.88d | 0d | Consultor; Gerente de Obras | 32h | 960 | 960 |
| 82 | 1.2.7.8 | Treinar equipe |  | 3d | 2017-03-15 | 2017-03-20 | 81 | 2017-03-13 | 2017-03-16 | 3d | 211.88d | 0d | Consultor; Datashow [8.3%] | 26h | 844 | 844 |
| 83 | 1.2.7.9 | Término do treinamento | milestone | 0d | 2017-03-20 | 2017-03-20 | 81, 82 | 2017-03-16 | 2017-03-16 | 0d | 211.88d |  |  |  |  |  |
| 84 | 1.3 | **CONTROLE** |  | 247d | 2017-01-30 | 2018-01-09 |  | 2017-01-26 | 2018-01-05 | 247d | 0d |  |  | 801h | 21,314 | 21,314 |
| 85 | 1.3.1 | Evidenciar e registrar |  | 140d | 2017-01-30 | 2017-08-11 | 22 | 2017-01-26 | 2017-08-09 | 140d | 0d |  |  |  |  |  |
| 86 | 1.3.2 | **Realizar verificação** |  | 12d | 2017-08-14 | 2017-08-29 |  | 2017-08-10 | 2017-08-25 | 12d | 0d |  |  | 56h | 1,960 | 1,960 |
| 87 | 1.3.2.1 | Pré-auditoria |  | 7d | 2017-08-14 | 2017-08-22 | 85 | 2017-08-10 | 2017-08-18 | 7d | 0d |  | Consultor | 56h | 1,960 | 1,960 |
| 88 | 1.3.2.2 | Implementar ações corretivas |  | 5d | 2017-08-23 | 2017-08-29 | 87 | 2017-08-21 | 2017-08-25 | 5d | 0d |  |  |  |  |  |

| ID | WBS | Task | Duration | Start | Finish | Predecessors | Baseline start | Baseline finish | Baseline duration | Total slack | Resources | Work | Cost | Baseline cost |
| --- | --- | --- | --- | --- | --- | --- | --- | --- | --- | --- | --- | --- | --- | --- |
| 89 | 1.3.3 | **Auditoria Interna** | 14d | 2017-08-23 | 2017-09-11 |  | 2017-08-21 | 2017-09-07 | 14d | 0d |  | 157h | 8,474 | 8,474 |
| 90 | 1.3.3.1 | Contratar empresa de consultoria | 5d | 2017-08-23 | 2017-08-29 | 88SS | 2017-08-21 | 2017-08-25 | 5d | 0d | Diretor [7.5%] | 3h | 150 | 150 |
| 91 | 1.3.3.2 | Agendar data da auditoria | 1d | 2017-08-30 | 2017-08-30 | 90 | 2017-08-28 | 2017-08-28 | 1d | 0d | Consultor | 8h | 280 | 280 |
| 92 | 1.3.3.3 | Comunicar a todos | 1d | 2017-08-31 | 2017-08-31 | 91 | 2017-08-29 | 2017-08-29 | 1d | 0d | Computador; Consultor | 16h | 320 | 320 |
| 93 | 1.3.3.4 | Realizar auditoria | 1d | 2017-09-01 | 2017-09-01 | 92 | 2017-08-30 | 2017-08-30 | 1d | 0d | Orgão Certificador | 8h | 4,800 | 4,800 |
| 94 | 1.3.3.5 | **Reunião de Análise Crítica** | 6d | 2017-09-04 | 2017-09-11 |  | 2017-08-31 | 2017-09-07 | 6d | 0d |  | 122h | 2,924 | 2,924 |
| 95 | 1.3.3.5.1 | Realizar reunião | 1d | 2017-09-04 | 2017-09-04 | 93 | 2017-08-31 | 2017-08-31 | 1d | 0d | Computador; Consultor; Datashow [25%]; Gerente Administrativo; Gerente Almoxarifado; Gerente Comercial; Gerente de Aquisições; Gerente de Compras; Gerente de Obras; Gerente de RH; Gerente Financeiro | 82h | 1,924 | 1,924 |
| 96 | 1.3.3.5.2 | Ajustes pós análise crítica | 5d | 2017-09-05 | 2017-09-11 | 95 | 2017-09-01 | 2017-09-07 | 5d | 0d | Representante da direção | 40h | 1,000 | 1,000 |
| 97 | 1.3.4 | **Auditoria externa** | 91d | 2017-09-05 | 2018-01-09 |  | 2017-09-01 | 2018-01-05 | 91d | 0d |  | 588h | 10,880 | 10,880 |
| 98 | 1.3.4.1 | Contratar órgão certificador | 70d | 2017-09-05 | 2017-12-11 | 96SS | 2017-09-01 | 2017-12-07 | 70d | 0d | Orgão Certificador | 560h |  |  |
| 99 | 1.3.4.2 | Agendar data da auditoria | 1d | 2017-12-12 | 2017-12-12 | 98 | 2017-12-08 | 2017-12-08 | 1d | 0d | Consultor | 8h | 280 | 280 |
| 100 | 1.3.4.3 | Contatar a todos | 2d | 2017-12-13 | 2017-12-14 | 99 | 2017-12-11 | 2017-12-12 | 2d | 0d |  |  |  |  |
| 101 | 1.3.4.4 | Auditoria externa da 1º fase | 3d | 2017-12-15 | 2017-12-19 | 100 | 2017-12-13 | 2017-12-15 | 3d | 0d | Diretor [33.3%] | 10h | 5,300 | 5,300 |
| 102 | 1.3.4.5 | **Reunião de análise Crítica** | 6d | 2017-12-20 | 2017-12-27 |  | 2017-12-18 | 2017-12-25 | 6d | 0d |  |  |  |  |
| 103 | 1.3.4.5.1 | Realizar reunião | 1d | 2017-12-20 | 2017-12-20 | 101 | 2017-12-18 | 2017-12-18 | 1d | 0d |  |  |  |  |
| 104 | 1.3.4.5.2 | Ajustes pós análise crítica | 5d | 2017-12-21 | 2017-12-27 | 103 | 2017-12-19 | 2017-12-25 | 5d | 0d |  |  |  |  |
| 105 | 1.3.4.6 | Auditoria externa da 2º fase | 3d | 2017-12-28 | 2018-01-01 | 104 | 2017-12-26 | 2017-12-28 | 3d | 0d | Diretor | 10h | 5,300 | 5,300 |
| 106 | 1.3.4.7 | **Reunião de análise Crítica** | 6d | 2018-01-02 | 2018-01-09 |  | 2017-12-29 | 2018-01-05 | 6d | 0d |  |  |  |  |
| 107 | 1.3.4.7.1 | Realizar reunião | 1d | 2018-01-02 | 2018-01-02 | 105 | 2017-12-29 | 2017-12-29 | 1d | 0d |  |  |  |  |
| 108 | 1.3.4.7.2 | Ajustes pós análise crítica | 5d | 2018-01-03 | 2018-01-09 | 107 | 2018-01-01 | 2018-01-05 | 5d | 0d |  |  |  |  |
