# Treinamento

Schedule from MS Project, 2017-07-04 to 2018-04-30.

## Calendars

- Padrão: Mon-Fri 09:00-12:00, 13:00-18:00; Sat-Sun off.

## Schedule

| ID | WBS | Task | Type | Duration | Start | Finish | Predecessors | Total slack |
| --- | --- | --- | --- | --- | --- | --- | --- | --- |
| 1 | 1 | **PROGRAMA GERMINAR** |  | 207.88d | 2017-07-04 | 2018-04-19 |  |  |
| 2 | 1.1 | **Planejamento** |  | 207.88d | 2017-07-04 | 2018-04-19 |  |  |
| 3 | 1.1.1 | Fazer mapeamento das unidades com impactados | manual | 5d | 2017-07-24 | 2017-07-28 |  |  |
| 4 | 1.1.2 | Alinhar área de Treinamento | manual | 1d | 2017-07-04 | 2017-07-04 |  |  |
| 5 | 1.1.3 | Levantamento da estratégia e lições aprendidas dos Treinamentos dos outros projetos | manual | 1d | 2017-07-04 | 2017-07-04 |  |  |
| 6 | 1.1.4 | Definir a estratégia de treinamento | manual | 5d | 2017-11-21 | 2017-11-27 |  |  |
| 7 | 1.2 | **Plano de Aula** |  | 58d | 2017-11-23 | 2018-02-12 |  | 0d |
| 8 | 1.2.1 | Definir Plano de Aula (CV) | manual | 7d | 2017-11-23 | 2017-12-01 | 6FS+21d |  |
| 9 | 1.2.2 | Fazer a grade de treinamentos | manual | 14d | 2017-12-04 | 2017-12-21 | 8 |  |
| 10 | 1.2.3 | Mapear usuários por curso | manual | 10d | 2018-01-08 | 2018-01-19 | 9FS+9d |  |
| 11 | 1.2.4 | Definir logística / infraestrutura dos treinamentos | manual | 10d | 2018-01-09 | 2018-01-22 | 9 |  |
| 12 | 1.2.5 | Setup Ambiente de Treinamento (Client) | manual | 13d | 2017-12-12 | 2017-12-28 |  |  |
| 13 | 1.2.6 | Definir metodologia de avaliação dos treinamentos | manual | 5d | 2018-02-06 | 2018-02-12 | 12 |  |
| 14 | 1.3 | **Desenvolvimento dos Materiais de treinamento** |  | 10d | 2018-02-23 | 2018-03-08 |  |  |
| 15 | 1.3.1 | **Semana 1 (23/02 - 01/03)** |  | 5d | 2018-02-23 | 2018-03-01 |  |  |
| 16 | 1.3.1.1 | Marketing | manual | 5d | 2018-02-23 | 2018-03-01 |  |  |
| 17 | 1.3.1.2 | Comercial | manual | 5d | 2018-02-23 | 2018-03-01 |  |  |
| 18 | 1.3.2 | **Semana 2 (02/03 - 08/03)** |  | 5d | 2018-03-02 | 2018-03-08 |  |  |
| 19 | 1.3.2.1 | Contas a Pagar | manual | 5d | 2018-03-02 | 2018-03-08 |  |  |
| 20 | 1.3.2.2 | Contas a Receber | manual | 5d | 2018-03-02 | 2018-03-08 |  |  |
| 21 | 1.3.2.3 | Fiscal | manual | 5d | 2018-03-02 | 2018-03-08 |  |  |
| 22 | 1.3.2.4 | Contabilidade | manual | 5d | 2018-03-02 | 2018-03-08 |  |  |
| 23 | 1.4 | **Treinamento** |  | 31d | 2018-03-19 | 2018-04-30 |  | 0d |
| 24 | 1.4.1 | Treinamento funcional - On the Job Testes | manual | 9d | 2018-03-19 | 2018-03-29 |  |  |
| 25 | 1.4.2 | Capacitação dos multiplicadores (Train the trainer) | manual | 9d | 2018-03-19 | 2018-03-29 |  |  |
| 26 | 1.4.3 | Execução dos Treinamentos | manual | 21d | 2018-04-02 | 2018-04-30 |  |  |
| 27 | 1.4.4 | Acompanhamento dos treinamentos | manual | 21d | 2018-04-02 | 2018-04-30 |  |  |
